# 20190612 Planning rwzi Nieuwveen DO-Oplevering

Schedule from MS Project, 2020-09-01 to 2022-08-23.
Royal HaskoningDHV

## Calendars

- Standard: Mon-Fri 08:00-12:00, 13:00-17:00; Sat-Sun off. Exceptions (off unless hours are given): 2020-12-21 to 2021-01-01 (kerstvakantie 2020), 2021-08-02 to 2021-08-21 (zomervakantie 2021), 2021-12-20 to 2021-12-31 (kerstvakantie 2021), 2022-08-01 to 2022-08-19 (zomervakantie 2022).

## Schedule

| ID | WBS | Task | Type | Duration | Start | Finish | Predecessors | Total slack | Free slack |
| --- | --- | --- | --- | --- | --- | --- | --- | --- | --- |
| 1 | 1 | **Activiteiten HHR** |  | 111d | 2020-10-19 | 2021-04-05 |  | 30d |  |
| 2 | 1.1 | **Aanbesteding en gunningsfase** |  | 111d | 2020-10-19 | 2021-04-05 |  | 30d |  |
| 3 | 1.1.1 | Voorbereiding aanbesteding |  | 30d | 2020-10-19 | 2020-11-30 | 4SF | 402d |  |
| 4 | 1.1.2 | Contractstukken op Tenderned | manual | 1d | 2020-11-30 | 2020-11-30 |  |  |  |
| 5 | 1.1.3 | Rekentijd aannemers + NVI |  | 88ed | 2020-11-30 | 2021-02-26 | 4 | 7.88d | 0d |
| 6 | 1.1.4 | Indienen aanbestedingsdocumenten aannemers | milestone | 0d | 2021-02-26 | 2021-02-26 | 5 | 0d |  |
| 7 | 1.1.5 | Beoordeling en voorlopige gunning |  | 10d | 2021-03-01 | 2021-03-12 | 6 | 0d |  |
| 8 | 1.1.6 | Alcatel periode |  | 21ed | 2021-03-15 | 2021-04-05 | 7FS+1d | 1.88d | 0d |
| 9 | 1.1.7 | Definitieve gunning | milestone | 0d | 2021-04-05 | 2021-04-05 | 8 | 0d |  |
| 10 | 2 | **Uitvoeringsfase** |  | 317d | 2021-04-12 | 2022-08-23 |  | 0d |  |
| 11 | 2.1 | Datum van aanvang (start werk) |  | 1d | 2021-04-12 | 2021-04-12 | 9FS+4d | 0d |  |
| 12 | 2.2 | **Werkzaamheden awzi Bodegraven** |  | 316d | 2021-04-13 | 2022-08-23 |  | 0d |  |
| 13 | 2.2.1 | **Engineering** |  | 130d | 2021-04-13 | 2021-11-01 |  | 0d |  |
| 14 | 2.2.1.1 | Engineering C/W/E onderdelen |  | 60d | 2021-04-13 | 2021-07-05 | 11 | 0d |  |
| 15 | 2.2.1.2 | Bestellen C/W/E onderdelen |  | 80d | 2021-06-22 | 2021-11-01 | 14FS-10d | 0d |  |
| 16 | 2.2.1.3 | Leegzetten NBT 1 en inmeting ruimerwerk |  | 3d | 2021-04-27 | 2021-04-29 | 14SS+10d | 303d |  |
| 17 | 2.2.2 | **Uitvoering werkzaamheden awzi C/W/E** |  | 201d | 2021-10-12 | 2022-08-23 |  | 0d |  |
| 18 | 2.2.2.1 | Inrichten werkterrein |  | 10d | 2021-10-19 | 2021-11-01 | 15FS-10d | 0d |  |
| 19 | 2.2.2.2 | Ombouw hoofdverdeler HVK-ALG-01;plaatsen MCC-WL-01/MRK-WL-01 |  | 40d | 2021-10-19 | 2021-12-13 | 18SS | 0d |  |
| 20 | 2.2.2.3 | TRI fase 1 Rooster/pomp |  | 45d | 2021-10-12 | 2021-12-13 | 21SS-5d | 156d |  |
| 21 | 2.2.2.4 | Fase 1 Aanpassing ontvanggedeelte en selector C/W/E |  | 40d | 2021-10-19 | 2021-12-13 | 19FF | 0d |  |
| 22 | 2.2.2.5 | TPI Fase 2, 3 en 4 chemicaliën |  | 65d | 2021-12-07 | 2022-03-21 | 23SS-5d | 96d |  |
| 23 | 2.2.2.6 | Fase 2 Aanpassingen anaerobe tank C/W/E |  | 20d | 2021-12-14 | 2022-01-24 | 21 | 0d |  |
| 24 | 2.2.2.7 | TPI Fase 3 en 4 pomp retourslib |  | 45d | 2022-02-15 | 2022-04-18 | 25SS-5d | 76d |  |
| 25 | 2.2.2.8 | Fase 3 Aanpassen nabezinktank 1 en retourslibgemaal 1 C/W/E |  | 20d | 2022-02-22 | 2022-03-21 | 23FS+20d | 0d |  |
| 26 | 2.2.2.9 | Fase 4 Aanpassen nabezinktank 2 en retourslibgemaal 2 C/W/E |  | 20d | 2022-03-22 | 2022-04-18 | 25 | 0d |  |
| 27 | 2.2.2.10 | Fase 5 Aanpassen effluentput C/W/E |  | 5d | 2022-04-19 | 2022-04-25 | 26 | 0d |  |
| 28 | 2.2.2.11 | Overige werkzaamheden C |  | 50d | 2022-04-26 | 2022-07-04 | 27 | 0d |  |
| 29 | 2.2.2.12 | Overige werkzaamheden W |  | 50d | 2022-04-26 | 2022-07-04 | 28SS | 21d |  |
| 30 | 2.2.2.13 | Overige werkzaamheden E |  | 60d | 2022-04-26 | 2022-07-18 | 28SS | 0d |  |
| 31 | 2.2.2.14 | Opname restpunten awzi |  | 1d | 2022-07-19 | 2022-07-19 | 30 | 0d |  |
| 32 | 2.2.2.15 | Restpunten/ Terreinafwerking |  | 10d | 2022-07-20 | 2022-08-23 | 31 | 0d |  |
| 33 | 2.2.2.16 | Opleverdossier |  | 50d | 2022-04-19 | 2022-06-28 | 31SF-15d | 26d |  |

| ID | WBS | Task | Duration | Start | Finish | Predecessors | Total slack | Free slack |
| --- | --- | --- | --- | --- | --- | --- | --- | --- |
| 34 | 2.3 | **Werkzaamheden AWTG Reeuwijk West** | 151d | 2021-05-25 | 2022-01-25 |  | 56d |  |
| 35 | 2.3.1 | Engineering C/W/E onderdelen lange levertijd | 40d | 2021-05-25 | 2021-07-19 | 11FS+30d | 56d | 0d |
| 36 | 2.3.2 | Bestellen C/W/E onderdelen lange levertijd | 80d | 2021-07-06 | 2021-11-15 | 35FS-10d | 176d | 0d |
| 37 | 2.3.3 | Werkplan TPI | 5d | 2021-06-08 | 2021-06-14 | 35SS+10d | 136d | 0d |
| 38 | 2.3.4 | Engineering gereed | 1d | 2021-07-20 | 2021-07-20 | 35 | 245d |  |
| 39 | 2.3.5 | Levertijd pompen + FAT | 80d | 2021-07-06 | 2021-11-15 | 36SS | 176d |  |
| 40 | 2.3.6 | Levertijd TPI | 70d | 2021-06-15 | 2021-10-11 | 37 | 136d | 0d |
| 41 | 2.3.7 | Levertijd schakelkast + FAT | 30d | 2021-07-06 | 2021-09-06 | 36SS | 226d |  |
| 42 | 2.3.8 | Plaatsen TPI | 5d | 2021-10-12 | 2021-10-18 | 40 | 136d | 0d |
| 43 | 2.3.9 | Proefdraaien TPI | 5d | 2021-10-19 | 2021-10-25 | 42 | 136d | 0d |
| 44 | 2.3.10 | Bedrijfsperiode TPI | 55d | 2021-10-26 | 2022-01-24 | 43 | 136d | 0d |
| 45 | 2.3.11 | Amoveren bestaande installaties C/W/E | 10d | 2021-10-26 | 2021-11-08 | 44SS | 140d | 0d |
| 46 | 2.3.12 | Civiele werkzaamheden | 10d | 2021-11-09 | 2021-11-22 | 45 | 155d | 15d |
| 47 | 2.3.13 | Werktuigbouwkundige werkzaamheden | 15d | 2021-11-09 | 2021-11-29 | 45 | 150d | 10d |
| 48 | 2.3.14 | Elektrotechnische werkzaamheden | 25d | 2021-11-09 | 2021-12-13 | 45 | 140d | 0d |
| 49 | 2.3.15 | Montage eind inspectie (WTB/ E) | 1d | 2021-12-14 | 2021-12-14 | 46, 47, 48 | 140d | 0d |
| 50 | 2.3.16 | I/O testen | 5d | 2021-12-15 | 2022-01-04 | 49 | 140d | 0d |
| 51 | 2.3.17 | PA Sotware implementeren | 1d | 2022-01-05 | 2022-01-05 | 50 | 140d | 0d |
| 52 | 2.3.18 | SAT capaciteitstest 1 | 2d | 2022-01-06 | 2022-01-07 | 51 | 140d | 0d |
| 53 | 2.3.19 | Inbedrijfname AWTG | 1d | 2022-01-10 | 2022-01-10 | 52 | 140d | 0d |
| 54 | 2.3.20 | 14 dagen test (storingsvrije periode) | 14ed | 2022-01-10 | 2022-01-24 | 53 | 631.88d | 1.88d |
| 55 | 2.3.21 | Restpunten/ Terreinafwerking | 5d | 2022-01-11 | 2022-01-17 | 53 | 140d | 0d |
| 56 | 2.3.22 | Opleverdossier | 80d | 2021-09-07 | 2022-01-11 | 35SS, 55SF | 145d | 10d |
| 57 | 2.3.23 | Vervroegde ingebruikneming AWTG | 1d | 2022-01-25 | 2022-01-25 | 54, 55, 56 | 135d |  |

| ID | WBS | Task | Duration | Start | Finish | Predecessors | Total slack | Free slack |
| --- | --- | --- | --- | --- | --- | --- | --- | --- |
| 58 | 2.4 | **Werkzaamheden AWTG Reeuwijk Brug Oost** | 151d | 2021-06-15 | 2022-02-15 |  | 56d |  |
| 59 | 2.4.1 | Engineering C/W/E onderdelen lange levertijd | 40d | 2021-06-15 | 2021-08-30 | 35SS+15d | 56d | 0d |
| 60 | 2.4.2 | Bestellen C/W/E onderdelen lange levertijd | 80d | 2021-07-27 | 2021-12-06 | 59FS-10d | 161d | 0d |
| 61 | 2.4.3 | Werkplan TPI | 5d | 2021-06-29 | 2021-07-05 | 59SS+10d | 56d | 0d |
| 62 | 2.4.4 | Engineering gereed | 1d | 2021-08-31 | 2021-08-31 | 59 | 230d |  |
| 63 | 2.4.5 | Levertijd pompen + FAT | 80d | 2021-07-27 | 2021-12-06 | 60SS | 161d |  |
| 64 | 2.4.6 | Levertijd TPI | 70d | 2021-07-06 | 2021-11-01 | 61 | 56d | 0d |
| 65 | 2.4.7 | Levertijd schakelkast + FAT | 30d | 2021-07-27 | 2021-09-27 | 60SS | 211d |  |
| 66 | 2.4.8 | Plaatsen TPI | 5d | 2021-11-02 | 2021-11-08 | 64 | 56d | 0d |
| 67 | 2.4.9 | Proefdraaien TPI | 5d | 2021-11-09 | 2021-11-15 | 66 | 56d | 0d |
| 68 | 2.4.10 | Bedrijfsperiode TPI | 55d | 2021-11-16 | 2022-02-14 | 67 | 56d | 0d |
| 69 | 2.4.11 | Amoveren bestaande installaties C/W/E | 10d | 2021-11-16 | 2021-11-29 | 68SS | 56d | 0d |
| 70 | 2.4.12 | Civiele werkzaamheden | 25d | 2021-11-30 | 2022-01-17 | 69 | 56d | 0d |
| 71 | 2.4.13 | Werktuigbouwkundige werkzaamheden | 10d | 2021-11-30 | 2021-12-13 | 69 | 71d | 15d |
| 72 | 2.4.14 | Elektrotechnische werkzaamheden | 25d | 2021-11-30 | 2022-01-17 | 69 | 56d | 0d |
| 73 | 2.4.15 | Montage eind inspectie (WTB/ E) | 1d | 2022-01-18 | 2022-01-18 | 70, 71, 72 | 56d | 0d |
| 74 | 2.4.16 | I/O testen | 5d | 2022-01-19 | 2022-01-25 | 73 | 56d | 0d |
| 75 | 2.4.17 | PA Sotware implementeren | 1d | 2022-01-26 | 2022-01-26 | 74 | 56d | 0d |
| 76 | 2.4.18 | SAT capaciteitstest 1 | 2d | 2022-01-27 | 2022-01-28 | 75 | 56d | 0d |
| 77 | 2.4.19 | Inbedrijfname AWTG | 1d | 2022-01-31 | 2022-01-31 | 76 | 56d | 0d |
| 78 | 2.4.20 | 14 dagen test (storingsvrije periode) | 14ed | 2022-01-31 | 2022-02-14 | 77 | 235.88d | 1.88d |
| 79 | 2.4.21 | Restpunten/ Terreinafwerking | 5d | 2022-02-01 | 2022-02-07 | 77 | 125d | 0d |
| 80 | 2.4.22 | Opleverdossier | 80d | 2021-09-28 | 2022-02-01 | 59SS, 79SF | 130d | 10d |
| 81 | 2.4.23 | Vervroegde ingebruikneming AWTG | 1d | 2022-02-15 | 2022-02-15 | 78, 79, 80 | 120d |  |

| ID | WBS | Task | Type | Duration | Start | Finish | Predecessors | Total slack | Free slack | Mijlpaal |
| --- | --- | --- | --- | --- | --- | --- | --- | --- | --- | --- |
| 82 | 2.5 | **Werkzaamheden AWTG Zwammerdam** |  | 201d | 2021-07-06 | 2022-05-17 |  | 55d |  |  |
| 83 | 2.5.1 | Engineering C/W/E onderdelen lange levertijd |  | 40d | 2021-07-06 | 2021-09-20 | 59SS+15d | 146d | 0d |  |
| 84 | 2.5.2 | Bestellen C/W/E onderdelen lange levertijd |  | 80d | 2021-09-07 | 2022-01-10 | 83FS-10d | 146d | 0d |  |
| 85 | 2.5.3 | Werkplan TPI |  | 5d | 2021-07-20 | 2021-07-26 | 83SS+10d | 171d | 0d |  |
| 86 | 2.5.4 | Engineering gereed |  | 1d | 2021-09-21 | 2021-09-21 | 83 | 215d |  |  |
| 87 | 2.5.5 | Levertijd pompen + FAT |  | 80d | 2021-09-07 | 2022-01-10 | 84SS | 146d |  |  |
| 88 | 2.5.6 | Levertijd TPI |  | 70d | 2021-07-27 | 2021-11-22 | 85 | 171d |  |  |
| 89 | 2.5.7 | Levertijd schakelkast + FAT |  | 30d | 2021-09-07 | 2021-10-18 | 84SS | 196d |  |  |
| 90 | 2.5.8 | Plaatsen TPI |  | 5d | 2022-02-15 | 2022-02-21 | 78 | 56d | 0d |  |
| 91 | 2.5.9 | Proefdraaien TPI |  | 5d | 2022-02-22 | 2022-02-28 | 90 | 56d | 0d |  |
| 92 | 2.5.10 | Bedrijfsperiode TPI |  | 55d | 2022-03-01 | 2022-05-16 | 91 | 56d | 0d |  |
| 93 | 2.5.11 | Amoveren bestaande installaties C/W/E |  | 10d | 2022-03-01 | 2022-03-14 | 92SS | 60d | 0d |  |
| 94 | 2.5.12 | Civiele werkzaamheden |  | 25d | 2022-03-15 | 2022-04-18 | 93 | 60d | 0d |  |
| 95 | 2.5.13 | Werktuigbouwkundige werkzaamheden |  | 10d | 2022-03-15 | 2022-03-28 | 93 | 75d | 15d |  |
| 96 | 2.5.14 | Elektrotechnische werkzaamheden |  | 25d | 2022-03-15 | 2022-04-18 | 93 | 60d | 0d |  |
| 97 | 2.5.15 | Montage eind inspectie (WTB/ E) |  | 1d | 2022-04-19 | 2022-04-19 | 94, 95, 96 | 60d | 0d |  |
| 98 | 2.5.16 | I/O testen |  | 5d | 2022-04-20 | 2022-04-26 | 97 | 60d | 0d |  |
| 99 | 2.5.17 | PA Sotware implementeren |  | 1d | 2022-04-27 | 2022-04-27 | 98 | 60d | 0d |  |
| 100 | 2.5.18 | SAT capaciteitstest 1 |  | 2d | 2022-04-28 | 2022-04-29 | 99 | 60d | 0d |  |
| 101 | 2.5.19 | Inbedrijfname AWTG |  | 1d | 2022-05-02 | 2022-05-02 | 100 | 60d | 0d |  |
| 102 | 2.5.20 | 14 dagen test (storingsvrije periode) |  | 14ed | 2022-05-02 | 2022-05-16 | 101 | 295.88d | 1.88d |  |
| 103 | 2.5.21 | Restpunten/ Terreinafwerking |  | 5d | 2022-05-03 | 2022-05-09 | 101 | 60d | 0d |  |
| 104 | 2.5.22 | Opleverdossier |  | 80d | 2022-01-11 | 2022-05-03 | 83SS, 103SF | 65d | 10d |  |
| 105 | 2.5.23 | Vervroegde ingebruikneming AWTG |  | 1d | 2022-05-17 | 2022-05-17 | 102, 103, 104 | 55d |  |  |
| 106 | 3 | Piggen transportleidingsysteem 3 AWTG's |  | 3d | 2020-09-01 | 2020-09-03 |  | 462d | 453d |  |
| 107 | 4 | Oplevering awzi en AWTG's | milestone | 1d | 2022-07-20 | 2022-07-20 | 106, 31 | 9d |  | UM |
